Schedule from MS Project, 2008-03-03 to 2009-06-22, status date 2008-09-10, costs in $.

## Calendars

- Standard: Mon-Fri 08:00-12:00, 13:00-17:00; Sat-Sun off.

## Resources

| Resource | Rate |
| --- | --- |
| Project Manager | 100 |
| Business Analyst | 80 |
| Architect | 120 |
| Developer - 1 | 50 |
| Technical Leader | 70 |
| Tester | 50 |
| User | 120 |
| Developer - 2 | 50 |
| Developer - 3 | 50 |

## Schedule

| ID | WBS | Task | Duration | Start | Finish | Predecessors | Baseline start | Baseline finish | Baseline duration | Total slack | Constraint | Resources | Work | Cost | Baseline cost |
| --- | --- | --- | --- | --- | --- | --- | --- | --- | --- | --- | --- | --- | --- | --- | --- |
| 1 | 1 | **PM Software** | 340.07d | 2008-03-03 | 2009-06-22 |  | 2008-03-03 | 2008-09-04 | 133.89d | 0d |  |  | 2734h | 191,210 | 205,130 |
| 2 | 1.1 | **Weekly Team Meeting** | 40.12d | 2008-03-03 | 2008-04-28 |  | 2008-03-03 | 2008-04-28 | 40.12d | 269.95d |  |  | 54h | 4,230 | 4,230 |
| 3 | 1.1.1 | Weekly Team Meeting 1 | 1h | 2008-03-03 | 2008-03-03 |  | 2008-03-03 | 2008-03-03 | 1h | 339.95d | start no earlier than 2008-03-03 | Project Manager; Business Analyst; Architect; Developer - 1; Technical Leader; Tester | 6h | 470 | 470 |
| 4 | 1.1.2 | Weekly Team Meeting 2 | 1h | 2008-03-10 | 2008-03-10 |  | 2008-03-10 | 2008-03-10 | 1h | 334.95d | start no earlier than 2008-03-10 | Project Manager; Business Analyst; Architect; Developer - 1; Technical Leader; Tester | 6h | 470 | 470 |
| 5 | 1.1.3 | Weekly Team Meeting 3 | 1h | 2008-03-17 | 2008-03-17 |  | 2008-03-17 | 2008-03-17 | 1h | 329.95d | start no earlier than 2008-03-17 | Project Manager; Business Analyst; Architect; Developer - 1; Technical Leader; Tester | 6h | 470 | 470 |
| 6 | 1.1.4 | Weekly Team Meeting 4 | 1h | 2008-03-24 | 2008-03-24 |  | 2008-03-24 | 2008-03-24 | 1h | 324.95d | start no earlier than 2008-03-24 | Project Manager; Business Analyst; Architect; Developer - 1; Technical Leader; Tester | 6h | 470 | 470 |
| 7 | 1.1.5 | Weekly Team Meeting 5 | 1h | 2008-03-31 | 2008-03-31 |  | 2008-03-31 | 2008-03-31 | 1h | 319.95d | start no earlier than 2008-03-31 | Project Manager; Business Analyst; Architect; Developer - 1; Technical Leader; Tester | 6h | 470 | 470 |
| 8 | 1.1.6 | Weekly Team Meeting 6 | 1h | 2008-04-07 | 2008-04-07 |  | 2008-04-07 | 2008-04-07 | 1h | 314.95d | start no earlier than 2008-04-07 | Project Manager; Business Analyst; Architect; Developer - 1; Technical Leader; Tester | 6h | 470 | 470 |
| 9 | 1.1.7 | Weekly Team Meeting 7 | 1h | 2008-04-14 | 2008-04-14 |  | 2008-04-14 | 2008-04-14 | 1h | 309.95d | start no earlier than 2008-04-14 | Project Manager; Business Analyst; Architect; Developer - 1; Technical Leader; Tester | 6h | 470 | 470 |
| 10 | 1.1.8 | Weekly Team Meeting 8 | 1h | 2008-04-21 | 2008-04-21 |  | 2008-04-21 | 2008-04-21 | 1h | 304.95d | start no earlier than 2008-04-21 | Project Manager; Business Analyst; Architect; Developer - 1; Technical Leader; Tester | 6h | 470 | 470 |
| 11 | 1.1.9 | Weekly Team Meeting 9 | 1h | 2008-04-28 | 2008-04-28 |  | 2008-04-28 | 2008-04-28 | 1h | 299.95d | start no earlier than 2008-04-28 | Project Manager; Business Analyst; Architect; Developer - 1; Technical Leader; Tester | 6h | 470 | 470 |
| 12 | 1.2 | **Weekly Status Meeting** | 40.12d | 2008-03-04 | 2008-04-29 |  | 2008-03-04 | 2008-04-29 | 40.12d | 268.95d |  |  | 18h | 1,980 | 1,980 |
| 13 | 1.2.1 | Weekly Status Meeting 1 | 1h | 2008-03-04 | 2008-03-04 |  | 2008-03-04 | 2008-03-04 | 1h | 338.95d | start no earlier than 2008-03-04 | Project Manager; User | 2h | 220 | 220 |
| 14 | 1.2.2 | Weekly Status Meeting 2 | 1h | 2008-03-11 | 2008-03-11 |  | 2008-03-11 | 2008-03-11 | 1h | 333.95d | start no earlier than 2008-03-11 | Project Manager; User | 2h | 220 | 220 |
| 15 | 1.2.3 | Weekly Status Meeting 3 | 1h | 2008-03-18 | 2008-03-18 |  | 2008-03-18 | 2008-03-18 | 1h | 328.95d | start no earlier than 2008-03-18 | Project Manager; User | 2h | 220 | 220 |
| 16 | 1.2.4 | Weekly Status Meeting 4 | 1h | 2008-03-25 | 2008-03-25 |  | 2008-03-25 | 2008-03-25 | 1h | 323.95d | start no earlier than 2008-03-25 | Project Manager; User | 2h | 220 | 220 |
| 17 | 1.2.5 | Weekly Status Meeting 5 | 1h | 2008-04-01 | 2008-04-01 |  | 2008-04-01 | 2008-04-01 | 1h | 318.95d | start no earlier than 2008-04-01 | Project Manager; User | 2h | 220 | 220 |
| 18 | 1.2.6 | Weekly Status Meeting 6 | 1h | 2008-04-08 | 2008-04-08 |  | 2008-04-08 | 2008-04-08 | 1h | 313.95d | start no earlier than 2008-04-08 | Project Manager; User | 2h | 220 | 220 |
| 19 | 1.2.7 | Weekly Status Meeting 7 | 1h | 2008-04-15 | 2008-04-15 |  | 2008-04-15 | 2008-04-15 | 1h | 308.95d | start no earlier than 2008-04-15 | Project Manager; User | 2h | 220 | 220 |
| 20 | 1.2.8 | Weekly Status Meeting 8 | 1h | 2008-04-22 | 2008-04-22 |  | 2008-04-22 | 2008-04-22 | 1h | 303.95d | start no earlier than 2008-04-22 | Project Manager; User | 2h | 220 | 220 |
| 21 | 1.2.9 | Weekly Status Meeting 9 | 1h | 2008-04-29 | 2008-04-29 |  | 2008-04-29 | 2008-04-29 | 1h | 298.95d | start no earlier than 2008-04-29 | Project Manager; User | 2h | 220 | 220 |
| 22 | 1.3 | **Requirements** | 14.25d | 2008-04-28 | 2008-05-16 |  | 2008-03-03 | 2008-03-21 | 14.5d | 0d |  |  | 113h | 9,560 | 9,560 |
| 23 | 1.3.1 | Prepare Requirements | 10d | 2008-04-28 | 2008-05-12 |  | 2008-03-03 | 2008-03-17 | 10d | 0d |  | Business Analyst | 80h | 6,400 | 6,400 |
| 24 | 1.3.2 | Review Requirements | 1d | 2008-05-12 | 2008-05-13 | 23 | 2008-03-17 | 2008-03-18 | 1d | 0d |  | Project Manager | 8h | 800 | 800 |
| 25 | 1.3.3 | Incorporate Review comments | 1d | 2008-05-13 | 2008-05-14 | 24 | 2008-03-18 | 2008-03-19 | 1d | 0d |  | Business Analyst | 8h | 640 | 640 |
| 26 | 1.3.4 | User Review | 1d | 2008-05-14 | 2008-05-15 | 25 | 2008-03-19 | 2008-03-20 | 1d | 0d |  | User | 8h | 960 | 960 |
| 27 | 1.3.5 | User Review Comments Incorporation | 1d | 2008-05-15 | 2008-05-16 | 26 | 2008-03-20 | 2008-03-21 | 1d | 0d |  | Business Analyst | 8h | 640 | 640 |
| 28 | 1.3.6 | Final Approval | 0.12d | 2008-05-16 | 2008-05-16 | 27 | 2008-03-21 | 2008-03-21 | 0.12d | 0d |  | User | 1h | 120 | 120 |

| ID | WBS | Task | Duration | Start | Finish | Predecessors | Baseline start | Baseline finish | Baseline duration | Total slack | Free slack | Resources | Work | Cost | Baseline cost |
| --- | --- | --- | --- | --- | --- | --- | --- | --- | --- | --- | --- | --- | --- | --- | --- |
| 29 | 1.4 | **High Level Design** | 14.5d | 2008-05-16 | 2008-06-05 | 22 | 2008-03-21 | 2008-04-15 | 16.62d | 0d |  |  | 113h | 8,760 | 8,760 |
| 30 | 1.4.1 | Prepare High Level Design | 10d | 2008-05-16 | 2008-05-30 |  | 2008-03-21 | 2008-04-04 | 10d | 0d |  | Technical Leader | 80h | 5,600 | 5,600 |
| 31 | 1.4.2 | Review HLD | 1d | 2008-05-30 | 2008-06-02 | 30 | 2008-04-09 | 2008-04-09 | 1d | 0d |  | Architect | 8h | 960 | 960 |
| 32 | 1.4.3 | Incorporate Review Comments | 1d | 2008-06-02 | 2008-06-03 | 31 | 2008-04-10 | 2008-04-10 | 1d | 0d |  | Technical Leader | 8h | 560 | 560 |
| 33 | 1.4.4 | User Review | 1d | 2008-06-03 | 2008-06-04 | 32 | 2008-04-11 | 2008-04-11 | 1d | 0d |  | User | 8h | 960 | 960 |
| 34 | 1.4.5 | User Review Comments Incorporation | 1d | 2008-06-04 | 2008-06-05 | 33 | 2008-04-14 | 2008-04-15 | 1d | 0d |  | Technical Leader | 8h | 560 | 560 |
| 35 | 1.4.6 | Final Approval | 0.12d | 2008-06-05 | 2008-06-05 | 34 | 2008-04-15 | 2008-04-15 | 0.12d | 0d |  | User | 1h | 120 | 120 |
| 36 | 1.5 | **Planning Module** | 67d | 2008-06-12 | 2008-09-15 | 29 | 2008-04-15 | 2008-06-12 | 42.5d | 72d | 0d |  | 316h | 16,600 | 16,600 |
| 37 | 1.5.1 | Prepare Low Level Design | 5d | 2008-06-12 | 2008-06-19 |  | 2008-04-15 | 2008-04-22 | 5d | 72d | 0d | Developer - 1 | 40h | 2,000 | 2,000 |
| 38 | 1.5.2 | LLD Review | 1d | 2008-06-19 | 2008-06-20 | 37 | 2008-04-23 | 2008-04-24 | 1d | 72d | 0d | Technical Leader | 8h | 560 | 560 |
| 39 | 1.5.3 | LLD Review Comments Incorporation | 1d | 2008-06-27 | 2008-06-30 | 38 | 2008-04-24 | 2008-04-25 | 1d | 72d | 0d | Developer - 1 | 8h | 400 | 400 |
| 40 | 1.5.4 | Unit Test Plan Preparation | 5d | 2008-07-01 | 2008-07-08 | 39 | 2008-04-25 | 2008-05-02 | 5d | 72d | 0d | Developer - 1 | 40h | 2,000 | 2,000 |
| 41 | 1.5.5 | UTP Review | 1d | 2008-07-08 | 2008-07-09 | 40 | 2008-05-02 | 2008-05-05 | 1d | 72d | 0d | Technical Leader | 8h | 560 | 560 |
| 42 | 1.5.6 | UTP Review Comments Incorporation | 1d | 2008-07-29 | 2008-07-30 | 41 | 2008-05-05 | 2008-05-06 | 1d | 72d | 0d | Developer - 1 | 8h | 400 | 400 |
| 43 | 1.5.7 | Coding | 15d | 2008-08-06 | 2008-08-27 | 42 | 2008-05-06 | 2008-05-27 | 15d | 72d | 0d | Developer - 1 | 120h | 6,000 | 6,000 |
| 44 | 1.5.8 | Unit Testing | 5d | 2008-09-01 | 2008-09-08 | 43 | 2008-05-27 | 2008-06-03 | 5d | 72d | 0d | Developer - 1 | 40h | 2,000 | 2,000 |
| 45 | 1.5.9 | Code Review | 3d | 2008-09-08 | 2008-09-11 | 44 | 2008-06-05 | 2008-06-10 | 3d | 72d | 0d | Technical Leader | 24h | 1,680 | 1,680 |
| 46 | 1.5.10 | Code Review Comments Incorporation | 2d | 2008-09-11 | 2008-09-15 | 45 | 2008-06-10 | 2008-06-12 | 2d | 72d | 0d | Developer - 1 | 16h | 800 | 800 |
| 47 | 1.5.11 | Move to Integration Testing | 0.5d | 2008-09-15 | 2008-09-15 | 46 | 2008-06-12 | 2008-06-12 | 0.5d | 72d |  | Developer - 1 | 4h | 200 | 200 |
| 48 | 1.6 | **Schedule Module** | 71d | 2008-09-15 | 2008-12-23 | 29 | 2008-04-15 | 2008-07-03 | 57.38d | 1d | 0d |  | 596h | 31,400 | 31,400 |
| 49 | 1.6.1 | Prepare Low Level Design | 10d | 2008-09-15 | 2008-09-29 |  | 2008-04-15 | 2008-04-29 | 10d | 1d | 0d | Developer - 1 | 80h | 4,000 | 4,000 |
| 50 | 1.6.2 | LLD Review | 2d | 2008-09-29 | 2008-10-01 | 49 | 2008-04-29 | 2008-05-01 | 2d | 1d | 0d | Technical Leader | 16h | 1,120 | 1,120 |
| 51 | 1.6.3 | LLD Review Comments Incorporation | 1d | 2008-10-01 | 2008-10-02 | 50 | 2008-05-01 | 2008-05-02 | 1d | 1d | 0d | Developer - 1 | 8h | 400 | 400 |
| 52 | 1.6.4 | Unit Test Plan Preparation | 10d | 2008-10-02 | 2008-10-16 | 51 | 2008-05-02 | 2008-05-16 | 10d | 1d | 0d | Developer - 1 | 80h | 4,000 | 4,000 |
| 53 | 1.6.5 | UTP Review | 2d | 2008-10-16 | 2008-10-20 | 52 | 2008-05-16 | 2008-05-20 | 2d | 1d | 0d | Technical Leader | 16h | 1,120 | 1,120 |
| 54 | 1.6.6 | UTP Review Comments Incorporation | 1d | 2008-10-20 | 2008-10-21 | 53 | 2008-05-20 | 2008-05-21 | 1d | 1d | 0d | Developer - 1 | 8h | 400 | 400 |
| 55 | 1.6.7 | Coding | 11.25d | 2008-11-07 | 2008-11-24 | 54 | 2008-05-21 | 2008-06-05 | 11.25d | 4.5d | 0d | Developer - 1 | 90h | 4,500 | 4,500 |
| 56 | 1.6.8 | Coding - 2 | 9.38d | 2008-11-24 | 2008-12-10 | 54 | 2008-06-03 | 2008-06-19 | 9.38d | 1d | 0d | Developer - 1 | 75h | 3,750 | 3,750 |
| 57 | 1.6.9 | Coding - 3 | 9.38d | 2008-10-21 | 2008-11-04 | 54 | 2008-06-02 | 2008-06-18 | 9.38d | 9.75d | 0d | Developer - 1 | 75h | 3,750 | 3,750 |
| 58 | 1.6.10 | Unit Testing | 4d | 2008-12-12 | 2008-12-18 | 55 | 2008-06-05 | 2008-06-11 | 4d | 4d |  | Developer - 1 | 32h | 1,600 | 1,600 |
| 59 | 1.6.11 | Unit Testing - 2 | 3d | 2008-12-18 | 2008-12-23 | 56 | 2008-06-19 | 2008-06-24 | 3d | 1d |  | Developer - 1 | 24h | 1,200 | 1,200 |
| 60 | 1.6.12 | Unit Testing - 3 | 3d | 2008-11-04 | 2008-11-07 | 57 | 2008-06-18 | 2008-06-23 | 3d | 9.75d | 0d | Developer - 1 | 24h | 1,200 | 1,200 |
| 61 | 1.6.13 | Code Review | 6d | 2008-11-07 | 2008-11-17 | 60 | 2008-06-23 | 2008-07-01 | 6d | 9.75d | 0d | Technical Leader | 48h | 3,360 | 3,360 |
| 62 | 1.6.14 | Code Review Comments Incorporation | 2d | 2008-12-10 | 2008-12-12 | 61 | 2008-07-01 | 2008-07-03 | 2d | 8d | 0d | Developer - 1 | 16h | 800 | 800 |
| 63 | 1.6.15 | Move to Integration Testing | 0.5d | 2008-12-12 | 2008-12-12 | 62 | 2008-07-03 | 2008-07-03 | 0.5d | 8d |  | Developer - 1 | 4h | 200 | 200 |

| ID | WBS | Task | Duration | Start | Finish | Predecessors | Baseline start | Baseline finish | Baseline duration | Total slack | Free slack | Resources | Work | Cost | Baseline cost |
| --- | --- | --- | --- | --- | --- | --- | --- | --- | --- | --- | --- | --- | --- | --- | --- |
| 64 | 1.7 | **Administration Module** | 61.5d | 2008-06-05 | 2008-09-01 | 29 | 2008-04-15 | 2008-06-09 | 39.5d | 0d |  |  | 316h | 16,600 | 16,600 |
| 65 | 1.7.1 | Prepare Low Level Design | 5d | 2008-06-05 | 2008-06-12 |  | 2008-04-15 | 2008-04-22 | 5d | 0d |  | Developer - 1 | 40h | 2,000 | 2,000 |
| 66 | 1.7.2 | LLD Review | 1d | 2008-06-12 | 2008-06-13 | 65 | 2008-04-22 | 2008-04-23 | 1d | 0d |  | Technical Leader | 8h | 560 | 560 |
| 67 | 1.7.3 | LLD Review Comments Incorporation | 1d | 2008-06-19 | 2008-06-20 | 66 | 2008-04-23 | 2008-04-24 | 1d | 0d |  | Developer - 1 | 8h | 400 | 400 |
| 68 | 1.7.4 | Unit Test Plan Preparation | 5d | 2008-06-20 | 2008-06-27 | 67 | 2008-04-24 | 2008-05-01 | 5d | 0d |  | Developer - 1 | 40h | 2,000 | 2,000 |
| 69 | 1.7.5 | UTP Review | 1d | 2008-06-27 | 2008-06-30 | 68 | 2008-05-01 | 2008-05-02 | 1d | 0d |  | Technical Leader | 8h | 560 | 560 |
| 70 | 1.7.6 | UTP Review Comments Incorporation | 1d | 2008-06-30 | 2008-07-01 | 69 | 2008-05-02 | 2008-05-05 | 1d | 0d |  | Developer - 1 | 8h | 400 | 400 |
| 71 | 1.7.7 | Coding | 15d | 2008-07-08 | 2008-07-29 | 70 | 2008-05-05 | 2008-05-26 | 15d | 0d |  | Developer - 1 | 120h | 6,000 | 6,000 |
| 72 | 1.7.8 | Unit Testing | 5d | 2008-07-30 | 2008-08-06 | 71 | 2008-05-26 | 2008-06-02 | 5d | 0d |  | Developer - 1 | 40h | 2,000 | 2,000 |
| 73 | 1.7.9 | Code Review | 3d | 2008-08-06 | 2008-08-11 | 72 | 2008-06-02 | 2008-06-05 | 3d | 0d |  | Technical Leader | 24h | 1,680 | 1,680 |
| 74 | 1.7.10 | Code Review Comments Incorporation | 2d | 2008-08-27 | 2008-08-29 | 73 | 2008-06-05 | 2008-06-09 | 2d | 0d |  | Developer - 1 | 16h | 800 | 800 |
| 75 | 1.7.11 | Move to Integration Testing | 0.5d | 2008-08-29 | 2008-09-01 | 74 | 2008-06-09 | 2008-06-09 | 0.5d | 0d |  | Developer - 1 | 4h | 200 | 200 |
| 76 | 1.8 | **Integration Testing** | 182.75d | 2008-04-28 | 2009-01-07 |  | 2008-03-03 | 2008-07-07 | 90.5d | 0d |  |  | 432h | 22,320 | 22,320 |
| 77 | 1.8.1 | Integration Test Plan Preparation | 10d | 2008-04-28 | 2008-05-12 |  | 2008-03-03 | 2008-03-05 | 2d | 76.25d | 0d | Tester | 80h | 4,000 | 4,000 |
| 78 | 1.8.2 | Integration Test Plan Review | 2d | 2008-05-12 | 2008-05-15 | 77 | 2008-03-17 | 2008-03-20 | 2d | 76.25d | 0d | Business Analyst | 16h | 1,280 | 1,280 |
| 79 | 1.8.3 | Integration Test Plan Review Comments Incorporation | 1d | 2008-05-15 | 2008-05-16 | 78 | 2008-03-20 | 2008-03-20 | 0.2d | 76.25d |  | Tester | 8h | 400 | 400 |
| 80 | 1.8.4 | Integration Testing - Planning Module | 10d | 2008-09-15 | 2008-09-29 | 79, 36 | 2008-06-12 | 2008-06-16 | 2d | 72d |  | Tester | 80h | 4,000 | 4,000 |
| 81 | 1.8.5 | Integration Testing - Schedule Module | 10d | 2008-12-23 | 2009-01-06 | 79, 48 | 2008-07-03 | 2008-07-07 | 2d | 1d |  | Tester | 80h | 4,000 | 4,000 |
| 82 | 1.8.6 | Integration Testing - Administration Module | 10d | 2008-09-01 | 2008-09-15 | 79, 64 | 2008-06-09 | 2008-06-11 | 2d | 0d |  | Tester | 80h | 4,000 | 4,000 |
| 83 | 1.8.7 | Integration Test Bug Fixing | 10d | 2008-12-23 | 2009-01-06 | 82 | 2008-06-24 | 2008-06-27 | 3.33d | 0d |  | Developer - 1 | 80h | 4,000 | 4,000 |
| 84 | 1.8.8 | Integration Test Sign Off | 1d | 2009-01-06 | 2009-01-07 | 83 | 2008-06-27 | 2008-06-30 | 1d | 0d |  | Business Analyst | 8h | 640 | 640 |
| 85 | 1.9 | **User Acceptance Testing** | 44.2d | 2009-01-07 | 2009-03-11 | 76 | 2008-07-07 | 2008-07-22 | 10.4d | 0d |  |  | 432h | 45,600 | 45,600 |
| 86 | 1.9.1 | User Acceptance Test Plan Preparation | 10d | 2009-01-07 | 2009-01-21 |  | 2008-07-07 | 2008-07-09 | 2d | 0d |  | User | 80h | 9,600 | 9,600 |
| 87 | 1.9.2 | User Acceptance Test Plan Review | 2d | 2009-01-21 | 2009-01-23 | 86 | 2008-07-09 | 2008-07-11 | 2d | 0d |  | Business Analyst | 16h | 1,280 | 1,280 |
| 88 | 1.9.3 | User Acceptance Test Plan Review Comments Incorporation | 1d | 2009-01-23 | 2009-01-26 | 87 | 2008-07-11 | 2008-07-11 | 0.2d | 0d |  | User | 8h | 960 | 960 |
| 89 | 1.9.4 | UAT - Planning Module | 10d | 2009-02-24 | 2009-03-11 | 88 | 2008-07-17 | 2008-07-22 | 2d | 0d |  | User | 80h | 9,600 | 9,600 |
| 90 | 1.9.5 | UAT - Schedule Module | 10d | 2009-02-09 | 2009-02-23 | 88 | 2008-07-15 | 2008-07-17 | 2d | 11.2d |  | User | 80h | 9,600 | 9,600 |
| 91 | 1.9.6 | UAT - Administration Module | 10d | 2009-01-26 | 2009-02-09 | 88 | 2008-07-11 | 2008-07-15 | 2d | 10.2d | 0d | User | 80h | 9,600 | 9,600 |
| 92 | 1.9.7 | User Acceptance Test Bug Fixing | 10d | 2009-02-09 | 2009-02-23 | 91 | 2008-07-15 | 2008-07-21 | 3.33d | 10.2d | 0d | Developer - 1 | 80h | 4,000 | 4,000 |
| 93 | 1.9.8 | User Acceptance Test Sign Off | 1d | 2009-02-23 | 2009-02-24 | 92 | 2008-07-21 | 2008-07-21 | 0.2d | 10.2d |  | User | 8h | 960 | 960 |

| ID | WBS | Task | Duration | Start | Finish | Predecessors | Baseline start | Baseline finish | Baseline duration | Total slack | Resources | Work | Cost | Baseline cost |
| --- | --- | --- | --- | --- | --- | --- | --- | --- | --- | --- | --- | --- | --- | --- |
| 94 | 1.10 | **Pilot Implementation** | 32d | 2009-03-11 | 2009-04-24 | 85 | 2008-07-22 | 2008-08-06 | 11.87d | 0d |  | 256h | 26,240 | 26,240 |
| 95 | 1.10.1 | Pilot Planning | 3d | 2009-03-11 | 2009-03-16 |  | 2008-07-22 | 2008-07-25 | 3d | 0d | Project Manager | 24h | 2,400 | 2,400 |
| 96 | 1.10.2 | Pilot Deployment | 3d | 2009-03-16 | 2009-03-19 | 95 | 2008-07-25 | 2008-07-30 | 3d | 0d | Technical Leader | 24h | 1,680 | 1,680 |
| 97 | 1.10.3 | Pilot Run | 20d | 2009-03-19 | 2009-04-16 | 96 | 2008-07-30 | 2008-08-05 | 4d | 0d | User | 160h | 19,200 | 19,200 |
| 98 | 1.10.4 | Pilot Run Bug Fixing | 5d | 2009-04-16 | 2009-04-23 | 97 | 2008-08-05 | 2008-08-06 | 1.67d | 0d | Developer - 1 | 40h | 2,000 | 2,000 |
| 99 | 1.10.5 | Pilot Run Sign Off | 1d | 2009-04-23 | 2009-04-24 | 98 | 2008-08-06 | 2008-08-06 | 0.2d | 0d | User | 8h | 960 | 960 |
| 100 | 1.11 | **Production Rollout** | 11d | 2009-04-24 | 2009-05-11 | 94 | 2008-08-06 | 2008-08-21 | 11d | 0d |  | 88h | 7,920 | 7,920 |
| 101 | 1.11.1 | Production Planning | 3d | 2009-04-24 | 2009-04-29 |  | 2008-08-06 | 2008-08-11 | 3d | 0d | Project Manager | 24h | 2,400 | 2,400 |
| 102 | 1.11.2 | Production Deployment | 3d | 2009-04-29 | 2009-05-04 | 101 | 2008-08-11 | 2008-08-14 | 3d | 0d | Technical Leader | 24h | 1,680 | 1,680 |
| 103 | 1.11.3 | Production Test | 3d | 2009-05-04 | 2009-05-07 | 102 | 2008-08-14 | 2008-08-19 | 3d | 0d | Business Analyst | 24h | 1,920 | 1,920 |
| 104 | 1.11.4 | Production Sign Off | 1d | 2009-05-07 | 2009-05-08 | 103 | 2008-08-19 | 2008-08-20 | 1d | 0d | User | 8h | 960 | 960 |
| 105 | 1.11.5 | Application Live | 1d | 2009-05-08 | 2009-05-11 | 104 | 2008-08-20 | 2008-08-21 | 1d | 0d | User | 8h | 960 | 960 |
| 106 | 1.12 | Contingency Buffer | 30d | 2009-05-11 | 2009-06-22 | 100 |  |  |  | 0d |  |  |  |  |
